# FAber Ellis Holt Gantt chart, 5 Dec 2012

Schedule from MS Project, 2012-09-14 to 2013-01-02, status date 2012-11-05, costs in $, A marks actual dates.

## Calendars

- Standard: Mon-Fri 08:00-12:00, 13:00-17:00; Sat-Sun off.

## Resources

| Resource | Rate |
| --- | --- |
| Dave Faber: Premises Manager | 25 |
| Niccole Ellis: Network Engineer | 25 |
| Brett Holt: Project Manager | 50 |
| Staff Accountant | 25 |

## Schedule

| ID | WBS | Task | Type | Duration | Start | Finish | Complete | Remaining | Baseline start | Baseline finish | Baseline duration | Total slack | Resources | Work | Actual work | Cost | Baseline cost | Actual cost |
| --- | --- | --- | --- | --- | --- | --- | --- | --- | --- | --- | --- | --- | --- | --- | --- | --- | --- | --- |
| 1 | 1 | **1.0 Inventory Overview** |  | 12d | 2012-09-14 A | 2012-10-01 A | 100% |  | 2012-09-14 | 2012-10-01 | 12d |  |  | 58h | 58h | 1,700 | 1,700 | 1,700 |
| 2 | 1.1 | 1.1 Inventory Verification | manual | 3d | 2012-09-14 A | 2012-09-18 A | 100% |  | 2012-09-14 | 2012-09-18 | 3d |  | Dave Faber: Premises Manager | 24h | 24h | 600 | 600 | 600 |
| 3 | 1.2 | Inventroy Verification Deliverable | milestone, manual | 0d | 2012-09-18 A | 2012-09-18 A | 100% |  | 2012-09-18 | 2012-09-18 | 0d |  |  |  |  |  |  |  |
| 4 | 1.3 | 1.2 Inventory Assessment | manual | 3d | 2012-09-19 A | 2012-09-21 A | 100% |  | 2012-09-19 | 2012-09-21 | 3d |  | Niccole Ellis: Network Engineer [50%]; Dave Faber: Premises Manager [50%] | 24h | 24h | 600 | 600 | 600 |
| 5 | 1.4 | 1.3 Requirement Compilation | manual | 5d | 2012-09-24 A | 2012-09-28 A | 100% |  | 2012-09-24 | 2012-09-28 | 5d |  | Brett Holt: Project Manager [25%] | 10h | 10h | 500 | 500 | 500 |
| 6 | 1.5 | Inventory Review | milestone, manual | 0d | 2012-10-01 A | 2012-10-01 A | 100% |  | 2012-10-01 | 2012-10-01 | 0d |  |  |  |  |  |  |  |
| 7 | 1.6 | Inentory Review and Requirements Document Deliverable | milestone, manual | 0d | 2012-10-01 A | 2012-10-01 A | 100% |  | 2012-10-01 | 2012-10-01 | 0d |  |  |  |  |  |  |  |
| 8 | 2 | **2.0 Analysis** |  | 21d | 2012-10-02 A | 2012-10-30 A | 100% |  | 2012-10-02 | 2012-10-30 | 21d |  |  | 167.44h | 167.44h | 5,548 | 5,548 | 5,548 |
| 9 | 2.1 | 2.1 Inventory Analysis and Requirements Gathering | manual | 9d | 2012-10-02 A | 2012-10-12 A | 100% |  | 2012-10-02 | 2012-10-12 | 9d |  | Niccole Ellis: Network Engineer [50%]; Brett Holt: Project Manager [50%] | 72h | 72h | 2,700 | 2,700 | 2,700 |
| 10 | 2.2 | 2.2 Blueprint Review of Modifications | manual | 5d | 2012-10-15 A | 2012-10-19 A | 100% |  | 2012-10-15 | 2012-10-19 | 5d |  | Brett Holt: Project Manager [33%]; Niccole Ellis: Network Engineer [33%]; Dave Faber: Premises Manager [33%] | 39.6h | 39.6h | 1,320 | 1,320 | 1,320 |
| 11 | 2.3 | 2.3 Price Comparisons | manual | 5d | 2012-10-22 A | 2012-10-26 A | 100% |  | 2012-10-22 | 2012-10-26 | 5d |  | Dave Faber: Premises Manager | 40h | 40h | 1,000 | 1,000 | 1,000 |
| 12 | 2.4 | 2.4 Prepare Analysis and Price Presentation | manual | 2d | 2012-10-29 A | 2012-10-30 A | 100% |  | 2012-10-29 | 2012-10-30 | 2d |  | Brett Holt: Project Manager [33%]; Niccole Ellis: Network Engineer [33%]; Dave Faber: Premises Manager [33%] | 15.84h | 15.84h | 528 | 528 | 528 |
| 13 | 3 | Presentation for Management Review | milestone, manual | 0d | 2012-10-31 A | 2012-10-31 A | 100% |  | 2012-10-31 | 2012-10-31 | 0d |  |  |  |  |  |  |  |
| 14 | 4 | Presentation Deliverable | milestone, manual | 0d | 2012-10-31 A | 2012-10-31 A | 100% |  | 2012-10-31 | 2012-10-31 | 0d |  |  |  |  |  |  |  |
| 15 | 5 | **3.0 Design/Bidding** |  | 21d | 2012-11-01 A | 2012-11-29 | 14% | 18.02d | 2012-11-01 | 2012-11-29 | 21d | 0d |  | 151.68h | 21.6h | 4,956 | 4,956 | 810 |
| 16 | 5.1 | 3.1 Update Design Based on Approval | manual | 6d | 2012-11-01 A | 2012-11-08 | 45% | 3.3d | 2012-11-01 | 2012-11-08 | 6d |  | Brett Holt: Project Manager [50%]; Niccole Ellis: Network Engineer [50%] | 48h | 21.6h | 1,800 | 1,800 | 810 |
| 17 | 5.2 | 3.2 Design Review with Depatments | manual | 6d | 2012-11-09 | 2012-11-16 |  |  | 2012-11-09 | 2012-11-16 | 6d |  | Dave Faber: Premises Manager [50%]; Niccole Ellis: Network Engineer [50%] | 48h |  | 1,200 | 1,200 |  |
| 18 | 5.3 | 3.3 Set Up Implementation Bids for Information Technology Companies | manual | 3d | 2012-11-19 | 2012-11-21 |  |  | 2012-11-19 | 2012-11-21 | 3d |  | Brett Holt: Project Manager [50%]; Dave Faber: Premises Manager [50%] | 24h |  | 900 | 900 |  |
| 19 | 5.4 | 3.4 Bidding review | manual | 2d | 2012-11-26 | 2012-11-27 |  |  | 2012-11-26 | 2012-11-27 | 2d |  | Brett Holt: Project Manager [33%]; Niccole Ellis: Network Engineer [33%]; Dave Faber: Premises Manager [33%] | 15.84h |  | 528 | 528 |  |
| 20 | 5.5 | 3.5 Meetings with finalists | manual | 2d | 2012-11-28 | 2012-11-29 |  |  | 2012-11-28 | 2012-11-29 | 2d |  | Brett Holt: Project Manager [33%]; Niccole Ellis: Network Engineer [33%]; Dave Faber: Premises Manager [33%] | 15.84h |  | 528 | 528 |  |
| 21 | 6 | Information Implementation Company Decision | milestone, manual | 0d | 2012-11-30 | 2012-11-30 |  |  | 2012-11-30 | 2012-11-30 | 0d |  |  |  |  |  |  |  |
| 22 | 7 | Inplementation Launch/Procuring HW/SW deliverable | milestone, manual | 0d | 2012-11-30 | 2012-11-30 |  |  | 2012-11-30 | 2012-11-30 | 0d |  |  |  |  |  |  |  |
| 23 | 8 | **4.0 Project Management** |  | 71d | 2012-09-14 | 2012-12-21 |  |  | 2012-09-14 | 2012-12-21 | 71d |  |  | 232.4h |  | 9,640 | 9,640 |  |
| 24 | 8.1 | 4.1 Manage the Project | manual | 71d | 2012-09-14 | 2012-12-21 |  |  | 2012-09-14 | 2012-12-21 | 71d |  | Brett Holt: Project Manager [20%] | 113.6h |  | 5,680 | 5,680 |  |
| 25 | 8.2 | 4.2 Design, Construction, Trials Mock-Up | manual | 15d | 2012-12-03 | 2012-12-21 |  |  | 2012-12-03 | 2012-12-21 | 15d |  | Brett Holt: Project Manager [33%]; Niccole Ellis: Network Engineer [33%]; Dave Faber: Premises Manager [33%] | 118.8h |  | 3,960 | 3,960 |  |
| 26 | 9 | Project Overview Deliverable | milestone, manual | 0d | 2012-12-21 | 2012-12-21 |  |  | 2012-12-21 | 2012-12-21 | 0d |  |  |  |  |  |  |  |
| 27 | 10 | Implementation Begins | milestone, manual | 0d | 2013-01-02 | 2013-01-02 |  |  | 2013-01-02 | 2013-01-02 | 0d |  |  |  |  |  |  |  |

| ID | WBS | Task | Type | Duration | Start | Finish | Baseline start | Baseline finish | Baseline duration | Resources | Work | Cost | Baseline cost |
| --- | --- | --- | --- | --- | --- | --- | --- | --- | --- | --- | --- | --- | --- |
| 28 | 11 | **5.0 Financial Accounting** |  | 71d | 2012-09-14 | 2012-12-21 | 2012-09-14 | 2012-12-21 | 71d |  | 194.4h | 4,860 | 4,860 |
| 29 | 11.1 | 5.1 Project Cost Estimates, Conversions | manual | 11d | 2012-09-14 | 2012-09-28 | 2012-09-14 | 2012-09-28 | 11d | Staff Accountant [30%] | 26.4h | 660 | 660 |
| 30 | 11.2 | 5.2 Prepare Financial Reports | manual | 70d | 2012-09-14 | 2012-12-20 | 2012-09-14 | 2012-12-20 | 70d | Staff Accountant [30%] | 168h | 4,200 | 4,200 |
| 31 | 11.3 | Final Billing | milestone, manual | 0d | 2012-12-21 | 2012-12-21 | 2012-12-21 | 2012-12-21 | 0d |  |  |  |  |
